# tpc-assembly

Schedule from MS Project, 2010-06-29 to 2010-09-21, A marks actual dates.
lbnl

## Calendars

- Standard: Mon-Fri 08:00-12:00, 13:00-17:00; Sat-Sun off.

## Schedule

| ID | WBS | Task | Type | Duration | Start | Finish | Predecessors | Complete | Remaining | Baseline start | Baseline finish | Baseline duration | Total slack | Free slack | Constraint |
| --- | --- | --- | --- | --- | --- | --- | --- | --- | --- | --- | --- | --- | --- | --- | --- |
| 1 | 1 | mesh plane fab |  | 7d | 2010-06-29 A | 2010-07-07 A |  | 100% |  | 2010-06-29 | 2010-07-07 | 7d |  |  |  |
| 2 | 2 | mesh plan ship to tamu |  | 2d | 2010-07-08 A | 2010-07-09 A | 1 | 100% |  | 2010-07-08 | 2010-07-09 | 2d |  |  |  |
| 3 | 3 | mesh plane assembly |  | 2d | 2010-08-05 A | 2010-08-06 A | 2 | 100% |  | 2010-08-05 | 2010-08-06 | 2d |  |  | finish no earlier than 2010-08-06 |
| 4 | 4 | mesh plane ship to LBNL |  | 2d | 2010-08-09 A | 2010-08-10 A | 3 | 100% |  | 2010-08-09 | 2010-08-10 | 2d |  |  |  |
| 5 | 5 | assemble back reflector | milestone | 0d | 2010-06-29 A | 2010-06-29 A |  | 100% |  | 2010-06-29 | 2010-06-29 | 0d |  |  |  |
| 6 | 6 | fab rods and spacers | milestone | 0d | 2010-06-29 A | 2010-06-29 A |  | 100% |  | 2010-06-29 | 2010-06-29 | 0d |  |  |  |
| 7 | 7 | assemble mesh planes to baseplate |  | 2d | 2010-08-11 A | 2010-08-12 A | 4 | 100% |  | 2010-08-11 | 2010-08-12 | 2d |  |  |  |
| 9 | 8 | gas system complete |  | 40d? | 2010-06-30 A | 2010-08-24 A |  | 100% |  | 2010-06-30 | 2010-08-24 | 40d? |  |  | finish no earlier than 2010-08-24 |
| 10 | 9 | final pressure test |  | 1d? | 2010-08-25 A | 2010-08-25 A | 9 | 100% |  | 2010-08-25 | 2010-08-25 | 1d? |  |  | finish no earlier than 2010-08-25 |
| 12 | 10 | field cage panel fab |  | 14d | 2010-06-30 A | 2010-07-19 A |  | 100% |  | 2010-06-30 | 2010-07-19 | 14d |  |  | finish no earlier than 2010-07-19 |
| 13 | 11 | field cage panel flycut and drill |  | 2d | 2010-09-01 | 2010-09-02 | 12 |  |  | 2010-09-01 | 2010-09-02 | 2d | 8d | 0d | start no earlier than 2010-09-01 |
| 14 | 12 | resistor (f.c.panel) prep |  | 2d | 2010-08-04 | 2010-08-05 |  |  |  | 2010-08-04 | 2010-08-05 | 2d | 28d | 20d | finish no earlier than 2010-08-05 |
| 15 | 13 | resistor jig design &fab |  | 7d | 2010-07-21 A | 2010-07-29 A |  | 100% |  | 2010-07-21 | 2010-07-29 | 7d |  |  | finish no earlier than 2010-07-29 |
| 16 | 14 | field cage panel assembly |  | 2d | 2010-09-03 | 2010-09-06 | 15, 14, 13 |  |  | 2010-09-03 | 2010-09-06 | 2d | 8d | 1d |  |
| 18 | 15 | support panel artwork fab |  | 4d | 2010-06-29 A | 2010-07-02 A |  | 100% |  | 2010-06-29 | 2010-07-02 | 4d |  |  | finish no earlier than 2010-07-02 |
| 19 | 16 | support panel fab |  | 7d | 2010-07-15 A | 2010-07-23 A | 18 | 100% |  | 2010-07-15 | 2010-07-23 | 7d |  |  | finish no earlier than 2010-07-23 |
| 20 | 17 | support panel assembly |  | 3d | 2010-09-03 A | 2010-09-07 | 19, 21 | 10% | 2.7d | 2010-09-06 | 2010-09-07 | 2d | 7d | 0d | finish no earlier than 2010-09-07 |
| 21 | 18 | resistor (support panel) prep |  | 1d | 2010-08-05 | 2010-08-05 |  |  |  | 2010-08-05 | 2010-08-05 | 1d | 28d | 21d | finish no earlier than 2010-08-05 |
| 22 | 19 | field cage module assembly |  | 1d? | 2010-09-08 | 2010-09-08 | 20, 23, 16 |  |  | 2010-09-08 | 2010-09-08 | 1d? | 7d | 0d |  |
| 23 | 20 | support post fab |  | 1d | 2010-07-21 A | 2010-07-21 A |  | 100% |  | 2010-07-21 | 2010-07-21 | 1d |  |  | finish no earlier than 2010-07-21 |
| 24 | 21 | assemble field cage modules to TPC |  | 2d | 2010-09-09 | 2010-09-10 | 22, 7 |  |  | 2010-09-09 | 2010-09-10 | 2d | 7d |  |  |
| 26 | 22 | PMT mount plane fab |  | 33d | 2010-07-28 A | 2010-09-10 |  | 80% | 6.6d | 2010-07-28 | 2010-09-10 | 33d | 0d |  | finish no earlier than 2010-09-10 |
| 27 | 23 | PMT back plane fab | milestone | 0d | 2010-06-29 A | 2010-06-29 A |  | 100% |  | 2010-06-29 | 2010-06-29 | 0d |  |  | finish no earlier than 2010-06-29 |
| 28 | 24 | PMT support tube fab |  | 1d | 2010-09-02 A | 2010-09-02 |  | 90% | 0.1d | 2010-09-02 | 2010-09-02 | 1d | 6d |  | start no earlier than 2010-09-02 |
| 29 | 25 | PMT to mount plane assemble |  | 1d | 2010-09-13 | 2010-09-13 | 28, 27, 26 |  |  | 2010-09-13 | 2010-09-13 | 1d | 0d |  |  |
| 30 | 26 | PMT subassembly assemble to TPC |  | 1d | 2010-09-14 | 2010-09-14 | 29 |  |  | 2010-09-14 | 2010-09-14 | 1d | 0d |  |  |
| 31 | 27 | PMT cable assemble to feedthroughs |  | 3d | 2010-09-15 | 2010-09-17 | 30 |  |  | 2010-09-15 | 2010-09-17 | 3d | 0d |  | finish no earlier than 2010-07-23 |
| 32 | 28 | PMT cabling to PMTs |  | 2d | 2010-09-20 | 2010-09-21 | 31, 10 |  |  | 2010-09-20 | 2010-09-21 | 2d | 0d |  |  |
| 33 | 29 | PMT distribution box |  | 7d | 2010-06-30 A | 2010-07-09 A |  | 100% |  | 2010-06-30 | 2010-07-09 | 7d |  |  | finish no earlier than 2010-06-30 |
| 34 | 30 | PMT gas shroud |  | 1d? | 2010-08-13 A | 2010-08-13 |  | 10% | 0.9d? | 2010-08-13 | 2010-08-13 | 1d? | 24d |  | finish no earlier than 2010-08-13 |
| 35 | 31 | plenum fab |  | 4d | 2010-07-14 A | 2010-07-19 A |  | 100% |  | 2010-07-14 | 2010-07-19 | 4d |  |  | finish no earlier than 2010-07-19 |
| 36 | 32 | plenum assemble |  | 1d | 2010-09-15 | 2010-09-15 | 35, 30 |  |  | 2010-09-15 | 2010-09-15 | 1d | 0d |  |  |
| 37 | 33 | HV cable bender fab |  | 2d | 2010-07-20 A | 2010-07-21 A |  | 100% |  | 2010-07-20 | 2010-07-21 | 2d |  |  | finish no earlier than 2010-07-21 |
| 38 | 34 | HV cable terminal fab |  | 3d | 2010-07-19 A | 2010-07-21 A |  | 100% |  | 2010-07-19 | 2010-07-21 | 3d |  |  | finish no earlier than 2010-07-21 |
| 39 | 35 | HV cable assemble to feedthroughs |  | 1d? | 2010-06-29 | 2010-06-29 |  |  |  | 2010-06-29 | 2010-06-29 | 1d? | 55d | 41d |  |
| 40 | 36 | HV cabling final |  | 2d | 2010-08-26 | 2010-08-27 | 37FF, 38, 10, 39 |  |  | 2010-08-26 | 2010-08-27 | 2d | 14d | 0d |  |
| 41 | 37 | gas line assemble |  | 1d | 2010-09-16 | 2010-09-16 | 36 |  |  | 2010-09-16 | 2010-09-16 | 1d | 0d |  |  |
| 42 | 38 | HV test chamber fab |  | 3d | 2010-08-05 A | 2010-08-09 |  | 40% | 1.8d | 2010-08-05 | 2010-08-09 | 3d | 26d | 12d | start no earlier than 2010-08-05 |
| 43 | 39 | HV test |  | 2d | 2010-08-26 | 2010-08-27 | 42, 40FF |  |  | 2010-08-26 | 2010-08-27 | 2d | 14d |  |  |
| 44 | 40 | Close up chamber |  | 2d | 2010-09-17 | 2010-09-20 | 43, 41, 34 |  |  | 2010-09-17 | 2010-09-20 | 2d | 0d |  |  |
| 45 | 41 | initial gas flow testing |  | 1d? | 2010-09-21 | 2010-09-21 | 44 |  |  | 2010-09-21 | 2010-09-21 | 1d? | 0d |  |  |
| 46 | 42 | Start Experiment | milestone | 0d | 2010-09-21 | 2010-09-21 | 45, 33 |  |  | 2010-09-21 | 2010-09-21 | 0d | 0d |  |  |
